# OB-05 - met kelder+liftput

Schedule from MS Project, 2003-01-12 to 2003-02-18, status date 2003-01-08.
BAM Nelissen Van Egteren

## Calendars

- ALLEEN WERKDAGEN: Mon-Fri 08:30-12:30, 13:00-17:00; Sat-Sun off. Exceptions (off unless hours are given): 2003-01-11 to 2003-01-12 08:30-12:30, 13:00-17:00, 2003-01-18 to 2003-01-19 08:30-12:30, 13:00-17:00, 2003-01-25 to 2003-01-26 08:30-12:30, 13:00-17:00, 2003-02-01 to 2003-02-02 08:30-12:30, 13:00-17:00, 2003-02-08 to 2003-02-09 08:30-12:30, 13:00-17:00, 2003-02-15 to 2003-02-16 08:30-12:30, 13:00-17:00.

## Schedule

| ID | WBS | Task | Type | Duration | Start | Finish | Predecessors | Total slack |
| --- | --- | --- | --- | --- | --- | --- | --- | --- |
| 1 | 1 | **ONDERBOUWFASE** |  | 38d | 2003-01-12 | 2003-02-18 |  | 0d |
| 2 | 1.1 | werkvloer liftput storten |  | 1d | 2003-01-12 | 2003-01-12 |  | 0d |
| 3 | 1.2 | liftputvloer kist+wapening |  | 1d | 2003-01-13 | 2003-01-13 | 2SS+1d | 0d |
| 4 | 1.3 | liftputvloer beton storten |  | 1d | 2003-01-14 | 2003-01-14 | 3SS+1d | 0d |
| 5 | 1.4 | liftputwanden kist+wapening |  | 1d | 2003-01-15 | 2003-01-15 | 4SS+1d | 0d |
| 6 | 1.5 | liftputwanden storten+ontkisten |  | 2d | 2003-01-16 | 2003-01-17 | 5SS+1d | 0d |
| 7 | 1.6 | zand aanvullen om liftput |  | 1d | 2003-01-18 | 2003-01-18 | 6SS+2d | 0d |
| 8 | 1.7 | werkvloer kelder randkist+beton |  | 3d | 2003-01-18 | 2003-01-20 | 7SS | 0d |
| 9 | 1.8 | keldervloer randkist stellen |  | 2d | 2003-01-20 | 2003-01-21 | 8SS+2d | 0d |
| 10 | 1.9 | keldervloer wapening vlechten |  | 4d | 2003-01-21 | 2003-01-24 | 9SS+1d | 0d |
| 11 | 1.10 | kelder vloerleidingen monteren |  | 2d | 2003-01-23 | 2003-01-24 | 10SS+2d | 0d |
| 12 | 1.11 | keldervloer beton storten |  | 1d | 2003-01-25 | 2003-01-25 | 11SS+2d | 0d |
| 13 | 1.12 | maatvoeren wanden+kolommen |  | 1d | 2003-01-26 | 2003-01-26 | 12SS+1d | 0d |
| 14 | 1.13 | kolommen kist+wapening+beton |  | 6d | 2003-01-27 | 2003-02-01 | 13SS+1d | 0d |
| 15 | 1.14 | kelderwanden bekisting stellen |  | 6d | 2003-01-27 | 2003-02-01 | 14SS | 0d |
| 16 | 1.15 | kelderwanden wapening vlechten |  | 6d | 2003-01-29 | 2003-02-03 | 15SS+2d | 0d |
| 17 | 1.16 | kelder sluitwandkist stellen |  | 6d | 2003-01-31 | 2003-02-05 | 16SS+2d | 0d |
| 18 | 1.17 | kelderwanden beton storten |  | 6d | 2003-02-02 | 2003-02-07 | 17SS+2d | 0d |
| 19 | 1.18 | kelderwanden ontkisten |  | 6d | 2003-02-03 | 2003-02-08 | 18SS+1d | 0d |
| 20 | 1.19 | beg.grondvloer vloerkist stellen |  | 5d | 2003-02-08 | 2003-02-12 | 19SS+5d | 0d |
| 21 | 1.20 | beg,grondvloer wapening vlechten |  | 5d | 2003-02-11 | 2003-02-15 | 20SS+3d | 0d |
| 22 | 1.21 | vloerleidingen monteren |  | 5d | 2003-02-12 | 2003-02-16 | 21SS+1d | 0d |
| 23 | 1.22 | beg.grondvloer beton storten |  | 1d | 2003-02-17 | 2003-02-17 | 22SS+5d | 0d |
| 24 | 1.23 | maatvoeren voor bovenbouw |  | 1d | 2003-02-18 | 2003-02-18 | 23SS+1d | 0d |
| 25 | 1.24 | start bovenbouw | milestone | 0d | 2003-02-18 | 2003-02-18 | 24SS+1d | 0d |
